# 3GPP_Work Plan

Schedule from MS Project, 2000-01-03 to 2004-12-01, A marks actual dates.

## Calendars

- Standard: Mon-Fri 08:00-12:00, 13:00-17:00; Sat-Sun off.

## Resources

| Resource |
| --- |
| NP |
| N1 |
| N2 |
| N3 |
| N4 |
| N5 |
| TP |
| T1 |
| T2 |
| T3 |
| RP |
| R1 |
| R2 |
| R3 |
| R4 |
| SP |
| S1 |
| S2 |
| S3 |
| S4 |
| S5 |
| PCG |
| GP |
| No |
| CN4 |
| ? |
| WG G2 |
| G2 |
| G1 |
| G4 |
| G3 |
| All |
| Generic |
| MLST |
| G5 |
| S3, G2 |
| WG T2 |
| GP,G1 |

## Schedule

| ID | WBS | Task | Duration | Start | Finish | Predecessors | Complete | Remaining | Baseline start | Baseline finish | Baseline duration | Total slack | Constraint | Resources | Work | Actual work | Text6 | Text9 | Text1 | Text8 | Text3 | Text7 | Text2 | Text4 | Text5 |
| --- | --- | --- | --- | --- | --- | --- | --- | --- | --- | --- | --- | --- | --- | --- | --- | --- | --- | --- | --- | --- | --- | --- | --- | --- | --- |
| 1 | 1 | Work Plan for Rel-4 - Version 2003 April 23rd | 1d | 2000-01-03 | 2000-01-03 |  |  |  | 2000-01-03 | 2000-01-03 | 1d | 1282d |  |  |  |  | Rel | 2044 |  |  |  |  |  |  |  |
| 2 | 2 | "CTRL + a" to display all the 3GPP fields | 1d | 2000-01-03 | 2000-01-03 |  |  |  | 2000-01-03 | 2000-01-03 | 1d | 1129d |  |  |  |  |  | 1462 |  |  |  |  |  |  |  |
| 3 | 3 | Content of Rel-4. Frozen at TSG # 11, March 2001 | 1d | 2000-01-03 | 2000-01-03 |  |  |  | 2000-01-03 | 2000-01-03 | 1d | 1282d |  |  |  |  | Rel | 2058 |  |  |  |  |  |  |  |
| 6 | 15 | **Miscelleneous UE Conformance Testing Activities** | 958d | 2001-04-02 A | 2004-12-01 |  | 50% | 483.11d | 2001-04-02 | 2003-03-03 | 501d | 0d |  | T1 | 36360h | 18023.9h | NA | 1861 | MISTST1 | Lidia |  |  |  |  |  |
| 7 | 15.1 | Optimisation of Test Time, RF Aspects (FDD) | 508d | 2001-09-24 A | 2003-09-03 |  | 70% | 152.4d | 2001-09-24 | 2003-03-03 | 376d | 325d | finish no earlier than 2003-09-03 | T1 | 4064h | 2844.8h | Rel Indep | 1862 | MISTST1-OpFDD |  | 34.121 | TSG |  |  |  |
| 8 | 15.2 | Optimisation of Test Time, RF Aspects (TDD) | 508d | 2001-09-24 A | 2003-09-03 |  | 70% | 152.4d | 2001-09-24 | 2003-03-03 | 376d | 325d | finish no earlier than 2003-09-03 | T1 | 4064h | 2844.8h | Rel Indep | 1863 | MISTST1-OpTDD |  | 34.122 | TSG |  |  |  |
| 9 | 15.3 | Extensions to R99 Test cases | 139.4w | 2001-04-02 A | 2003-12-02 |  | 70% | 41.82w | 2001-04-02 | 2002-12-02 | 87.2w | 261d | finish no earlier than 2003-12-02 | T1 | 5576h | 3903.2h |  | 1907 | MISTST1-Ext |  | 34.123 pts 1,2 | TSG |  |  |  |
| 10 | 15.4 | Extension to R99 Test cases - TTCN | 439d | 2002-06-28 A | 2004-03-03 |  | 50% | 219.5d | 2002-06-28 | 2003-03-03 | 177d | 195d | finish no earlier than 2004-03-03 | T1 | 3512h | 1756h |  |  |  |  |  | TSG |  |  |  |
| 11 | 15.5 | Creation of R99 TCs for TDD - prose | 719d | 2001-10-01 A | 2004-07-01 |  | 50% | 359.5d | 2001-10-01 | 2002-09-27 | 260d | 109d | finish no earlier than 2004-07-01 | T1 | 5752h | 2876h |  |  | MISTST1-TDD |  | 34.123-1 | TSG |  |  |  |
| 12 | 15.6 | Creation of R99 TCs for TDD - TTCN | 587d | 2002-09-03 | 2004-12-01 |  |  |  | 2002-09-03 | 2003-03-03 | 130d | 0d | finish no earlier than 2004-12-01 | T1 | 4696h |  |  |  |  |  |  | TSG |  |  |  |
| 13 | 15.7 | Review all other work items for impact on new or exiting 34 series specs. | 25.8w | 2002-07-02 | 2002-12-27 |  |  |  | 2002-07-02 | 2002-12-27 | 25.8w | 503d | finish no earlier than 2002-12-27 | T1 | 1032h |  |  | 1908 | MISTST1 |  | 34.121,122,123,125 |  |  |  |  |
| 14 | 46 | **Facsimile** | 89d | 2000-02-22 A | 2000-06-23 A |  | 100% |  | 2000-02-22 | 2000-06-23 | 89d |  |  | S1 | 4376h | 4376h | Rel-4 | 1340 | FAX | Alain |  | TSG |  |  |  |
| 15 | 46.1 | **Real Time Fax** | 89d | 2000-02-22 A | 2000-06-23 A |  | 100% |  | 2000-02-22 | 2000-06-23 | 89d |  |  | S2 | 3664h | 3664h |  | 1341 | FAX-RT |  |  |  | CCaR |  |  |
| 16 | 46.1.1 | Terminal capabilities, AT commands | 89d | 2000-02-22 A | 2000-06-23 A |  | 100% |  | 2000-02-22 | 2000-06-23 | 89d |  | finish no earlier than 2000-06-23 | T2 | 712h | 712h |  | 1808 |  |  | 21.904, 27.007 |  | CCaR |  |  |
| 17 | 46.1.2 | Signalling aspects (e.g. ICM) | 89d | 2000-02-22 A | 2000-06-23 A |  | 100% |  | 2000-02-22 | 2000-06-23 | 89d |  | start no earlier than 2000-02-22 | N1 | 712h | 712h |  | 1343 |  |  |  |  | CCaR |  |  |
| 18 | 46.1.3 | Service provision | 89d | 2000-02-22 A | 2000-06-23 A |  | 100% |  | 2000-02-22 | 2000-06-23 | 89d |  | finish no earlier than 2000-06-23 | N3 | 712h | 712h |  | 1648 |  |  | 23.146 |  | CCaR |  |  |
| 19 | 46.1.4 | Review whether service/stage 1 aspects need to be aligned | 51d | 2000-04-14 A | 2000-06-23 A |  | 100% |  | 2000-04-14 | 2000-06-23 | 51d |  | finish no earlier than 2000-12-14 | S1 | 408h | 408h |  | 1345 |  |  |  |  | CCaR |  |  |
| 20 | 46.1.5 | Review whether architecture/stage 2 aspects need to be aligned | 51d | 2000-04-14 A | 2000-06-23 A |  | 100% |  | 2000-04-14 | 2000-06-23 | 51d |  | finish no earlier than 2000-12-14 | S2 | 408h | 408h |  | 1346 |  |  |  |  | CCaR |  |  |
| 21 | 47 | Transparent End-to-End PS mobile streaming application | 253d | 2000-04-03 A | 2001-03-21 A |  | 100% |  | 2000-04-03 | 2001-03-21 | 253d |  | finish no earlier than 2000-12-29 | S4 | 2024h | 2024h | Rel-4 | 1539 | PSTREAM | Paolo | 26.233, 26.234 | TSG |  |  |  |
| 22 | 48 | **Multimedia Messaging** | 277d | 2000-02-22 A | 2001-03-14 |  | 99% | 0d | 2000-02-22 | 2001-03-14 | 277d | 0d |  | T2 | 12208h | 10661.6h | Rel-4 | 1818 | MMS | Friedhelm | 22.140, 23.140 | TSG | Mes | Josef Laumen, Siemens | Josef.Laumen@SAL.SIEMENS.DE |
| 23 | 48.1 | Definition of service requirements | 72d | 2000-02-22 A | 2000-05-31 A |  | 100% |  | 2000-02-22 | 2000-05-31 | 72d |  | start no earlier than 2000-02-22 | S1 | 576h | 576h |  | 136 | MMS |  |  |  | Mes |  |  |
| 24 | 48.2 | Review of definition of service requirements | 205d | 2000-06-01 A | 2001-03-14 A | 23 | 100% |  | 2000-06-01 | 2001-03-14 | 205d |  | finish no earlier than 2000-09-08 | T2 | 1640h | 1640h |  | 1819 |  |  | 22.140, 23.140 | TSG | Mes | Josef Laumen, Siemens |  |
| 25 | 48.3 | **Technical Realisation** | 243d | 2000-04-10 A | 2001-03-14 A |  | 100% |  | 2000-04-10 | 2001-03-14 | 243d |  |  | T2 | 7776h | 7776h |  | 1820 |  |  | 22.140, 23.140 | TSG | Mes | Josef Laumen, Siemens | Josef.Laumen@SAL.SIEMENS.DE |
| 26 | 48.3.1 | Review of definition of reference Achitecture model | 243d | 2000-04-10 A | 2001-03-14 A |  | 100% |  | 2000-04-10 | 2001-03-14 | 243d |  | finish no earlier than 2001-03-14 | T2 | 1944h | 1944h |  | 1821 |  |  | 22.140, 23.140 | TSG | Mes | Josef Laumen, Siemens | Josef.Laumen@SAL.SIEMENS.DE |
| 27 | 48.3.2 | "Fulfill Requirements of Stage 1" | 243d | 2000-04-10 A | 2001-03-14 A |  | 100% |  | 2000-04-10 | 2001-03-14 | 243d |  | finish no earlier than 2001-03-14 | T2 | 1944h | 1944h |  | 1822 |  |  | 22.140, 23.140 | TSG | Mes | Josef Laumen, Siemens | Josef.Laumen@SAL.SIEMENS.DE |
| 28 | 48.3.3 | Definition of MMS primitives in Stage 2 | 243d | 2000-04-10 A | 2001-03-14 A |  | 100% |  | 2000-04-10 | 2001-03-14 | 243d |  | finish no earlier than 2001-03-14 | T2 | 1944h | 1944h |  | 1823 |  |  | 22.140, 23.140 | TSG | Mes | Josef Laumen, Siemens | Josef.Laumen@SAL.SIEMENS.DE |

Notes:
- 7: It is believed that the current R99 test spec. can be optimised for faster overall test times
- 8: It is believed that the current R99 test spec. can be optimised for faster overall test times
- 9: Further test coverage of the R99 specification to cover supplementry services
- 13: Can't start until most core specs are stable
- 15: postponed from R99 to R00, SP-000169
- 27: e.g. minimum set of media formats, media format conversion, personalization of MMS.

| ID | WBS | Task | Type | Duration | Start | Finish | Complete | Remaining | Baseline start | Baseline finish | Baseline duration | Total slack | Constraint | Resources | Work | Actual work | Text1 | Text2 | Text6 | Text8 | Text9 | Text4 | Text5 | Text7 | Text3 |
| --- | --- | --- | --- | --- | --- | --- | --- | --- | --- | --- | --- | --- | --- | --- | --- | --- | --- | --- | --- | --- | --- | --- | --- | --- | --- |
| 29 | 49 | **Transcoder-Free Operation** |  | 325d | 2000-01-03 A | 2001-03-30 | 99% | 0d | 2000-01-03 | 2001-03-30 | 325d | 0d |  | N4 | 13040h | 10440h | TrFO | Cod | Rel-4 | Kimmo | 1541 |  |  |  |  |
| 30 | 49.1 | **OoBTC solution** |  | 325d | 2000-01-03 A | 2001-03-30 A | 100% |  | 2000-01-03 | 2001-03-30 | 325d |  |  | N4 | 8440h | 8440h | TRFO-OOBTC | Cod |  |  | 112 | Tosshiyuki Tamura, NEC | tamurato@elsf.ncos.nec.co.jp | WG |  |
| 31 | 49.1.1 | implementation in UTRAN |  | 145d | 2000-09-11 A | 2001-03-30 A | 100% |  | 2000-09-11 | 2001-03-30 | 145d |  | finish no earlier than 2001-03-30 | R3 | 1160h | 1160h | TRFO-OOBTC-UTRAN |  |  |  | 1512 | Alexander Vesely, Siemens | alexander.vesely@SIEMENS.AT | TSG | 25.401, 25.410, 25.413, 25.415, 23.153 |
| 32 | 49.1.2 | Impact on architecture, Principles and Terminology |  | 210d | 2000-01-03 A | 2000-10-20 A | 100% |  | 2000-01-03 | 2000-10-20 | 210d |  | finish no earlier than 2000-10-20 | S2 | 1680h | 1680h |  | Cod |  |  | 896 |  |  |  |  |
| 33 | 49.1.3 | Codec Negotiation between UE and MSC |  | 125d | 2000-08-14 A | 2001-02-02 A | 100% |  | 2000-08-14 | 2001-02-02 | 125d |  | finish no earlier than 2001-02-02 | N1 | 1000h | 1000h |  | Cod |  |  | 1657 | Andrew Howell / Motorola |  | TSG | 24.008, 23.009, 23.108, (29.002) |
| 34 | 49.1.4 | Codec Negotiation inter MSC |  | 125d | 2000-07-03 A | 2000-12-22 A | 100% |  | 2000-07-03 | 2000-12-22 | 125d |  | finish no earlier than 2000-12-22 | N4 | 1000h | 1000h |  | Cod |  |  | 115 |  |  |  |  |
| 35 | 49.1.5 | Bearer establishment inter MSC |  | 125d | 2000-07-03 A | 2000-12-22 A | 100% |  | 2000-07-03 | 2000-12-22 | 125d |  | finish no earlier than 2000-12-22 | N4 | 1000h | 1000h |  | Cod |  |  | 894 |  |  | TSG | 23.153 |
| 36 | 49.2 | **Speech Transcoder: Location and Control at the UMTS Core Network Border** |  | 125d | 2000-04-10 A | 2000-09-29 A | 100% |  | 2000-04-10 | 2000-09-29 | 125d |  |  | S2 | 2000h | 2000h | TRFO-STLC | Cod |  |  | 905 |  |  | WG |  |
| 37 | 49.2.1 | Transcoder at Edge |  | 125d | 2000-04-10 A | 2000-09-29 A | 100% |  | 2000-04-10 | 2000-09-29 | 125d |  | finish no earlier than 2000-09-29 | NP | 1000h | 1000h |  | Cod |  |  | 124 |  |  |  |  |
| 38 | 50 | **GERAN improvements 1 (Gb over IP)** |  | 225d | 2000-05-09 A | 2001-03-19 A | 100% |  | 2000-05-09 | 2001-03-19 | 225d |  |  | GP | 6472h | 6472h | GEIMP1 |  | Rel-4 | Paolo | 2310 |  |  | TSG |  |
| 39 | 50.1 | **Gb over IP (Ip-fication of Gb)** |  | 225d | 2000-05-09 A | 2001-03-19 A | 100% |  | 2000-05-09 | 2001-03-19 | 225d |  |  | GP | 4672h | 4672h | GbIP |  |  | Paolo | 2311 |  |  | TSG |  |
| 40 | 50.1.1 | Concept |  | 134d | 2000-05-09 A | 2000-11-10 A | 100% |  | 2000-05-09 | 2000-11-10 | 134d |  |  | GP | 1072h | 1072h |  |  |  |  | 2312 |  |  | TSG |  |
| 41 | 50.1.2 | Changes to 08.16, 08.18 |  | 225d | 2000-05-09 A | 2001-03-19 A | 100% |  | 2000-05-09 | 2001-03-19 | 225d |  |  | GP | 1800h | 1800h |  |  |  |  | 2313 |  |  | TSG |  |
| 42 | 51 | **GERAN improvements 2 (NACC)** |  | 815d | 2000-11-06 A | 2003-12-19 | 80% | 159.32d | 2000-11-06 | 2003-12-19 | 815d | 248d |  | GP | 24616h | 13616h | GEIMP2 |  | Rel-4 | Paolo | 2314 |  |  | TSG |  |
| 43 | 51.1 | **Gb enhancements** |  | 155d | 2000-11-06 A | 2001-06-08 A | 100% |  | 2000-11-06 | 2001-06-08 | 155d |  |  | GP | 7440h | 7440h | Gben |  |  | Paolo | 2315 |  |  | TSG |  |
| 44 | 51.1.1 | **Intra BSC NACC (Network Assisted Cell Change)** |  | 155d | 2000-11-06 A | 2001-06-08 A | 100% |  | 2000-11-06 | 2001-06-08 | 155d |  |  | GP | 6200h | 6200h |  |  |  |  | 2316 |  |  | TSG |  |
| 45 | 51.1.1.1 | Concept |  | 155d | 2000-11-06 A | 2001-06-08 A | 100% |  | 2000-11-06 | 2001-06-08 | 155d |  | finish no earlier than 2001-06-08 | GP | 1240h | 1240h |  |  |  |  | 2420 |  |  | TSG |  |
| 46 | 51.1.1.2 | Changes in 03.64 |  | 155d | 2000-11-06 A | 2001-06-08 A | 100% |  | 2000-11-06 | 2001-06-08 | 155d |  | finish no earlier than 2001-06-08 | GP | 1240h | 1240h |  |  |  |  | 2317 |  |  | TSG |  |
| 47 | 51.1.1.3 | Changes in 04.60 |  | 155d | 2000-11-06 A | 2001-06-08 A | 100% |  | 2000-11-06 | 2001-06-08 | 155d |  | finish no earlier than 2001-06-08 | GP | 1240h | 1240h |  |  |  |  | 2318 |  |  | TSG |  |
| 48 | 51.1.1.4 | Changes in 44.008 |  | 155d | 2000-11-06 A | 2001-06-08 A | 100% |  | 2000-11-06 | 2001-06-08 | 155d |  | finish no earlier than 2001-06-08 | GP | 1240h | 1240h |  |  |  |  | 2319 |  |  | TSG |  |
| 49 | 51.2 | Start Testing | milestone | 0d | 2001-06-04 | 2001-06-04 |  |  | 2001-06-04 | 2001-06-04 | 0d | 913d | start no earlier than 2001-06-04 |  |  |  |  |  |  |  |  |  |  |  |  |
| 50 | 51.3 | **MS conformance test for Intra BSC NACC** |  | 536d | 2001-11-30 A | 2003-12-19 | 50% | 268d | 2001-11-30 | 2003-12-19 | 536d | 248d |  | GP | 10656h | 5328h | GEIMP2-Msconf |  |  |  |  |  |  |  |  |
| 51 | 51.3.1 | Changes in 51.010 |  | 398d | 2001-11-30 A | 2003-12-19 | 50% | 199d | 2001-11-30 | 2003-12-19 | 398d | 248d | finish no earlier than 2003-12-19 | G5; G4 | 6368h | 3184h |  |  |  |  |  |  |  |  |  |
| 52 | 52 | **GERAN improvements 4 (Delayed TBF)** |  | 105d | 2001-01-15 A | 2001-06-08 A | 100% |  | 2001-01-15 | 2001-06-08 | 105d |  |  | GP | 3960h | 3960h | GEIMP4 |  | Rel-4 | Paolo | 2324 |  |  | TSG |  |
| 53 | 52.1 | **Gb enhancements 2** |  | 105d | 2001-01-15 A | 2001-06-08 A | 100% |  | 2001-01-15 | 2001-06-08 | 105d |  |  | GP | 3120h | 3120h | GEIMP4-Gben2 |  |  |  | 2325 |  |  | TSG |  |
| 54 | 52.1.1 | stage 2 |  | 105d | 2001-01-15 A | 2001-06-08 A | 100% |  | 2001-01-15 | 2001-06-08 | 105d |  | finish no earlier than 2001-06-08 | GP | 840h | 840h |  |  |  |  | 2429 |  |  |  |  |

Notes:
- 29: Lead given to CN4 from CN / [DAB 28/11/00]
- 31: moved according to NP-000575
- 32: e.g. study cascading TrFO/TFO/TrFO
- 33: the link to NP-000085has been deleted because refering to a R99 status sheet / One common set of codec negotiation procedures will be specified as in ID1656.
- 34: Bearer establishment inter MSC. TS 23.153 R99 part complete. capabilities moved to annex + list of open issues
- 35: Bearer establishment inter MSC. TS 23.153 R99 part complete. capabilities moved to annex. / See NP-000127 / Open issues: / Handling of Conference Calls; / Handling of Multi Party Supplementary Services; / Handling of Handover UMTS to GSM; / Handling of Sending a ...
- 36: WI description and Tdoc S2-99352 / Speech Transcoder: Location and Control at the UMTS Core Network Border
- 37: WI description and Tdoc S2-99352...
- 50: Started

| ID | WBS | Task | Type | Duration | Start | Finish | Predecessors | Complete | Remaining | Baseline start | Baseline finish | Baseline duration | Total slack | Free slack | Constraint | Resources | Work | Actual work | Text7 | Text9 | Text1 | Text4 | Text6 | Text8 | Text2 | Text3 | Text5 |
| --- | --- | --- | --- | --- | --- | --- | --- | --- | --- | --- | --- | --- | --- | --- | --- | --- | --- | --- | --- | --- | --- | --- | --- | --- | --- | --- | --- |
| 55 | 52.1.2 | **Stage 3 (changes in 44.060)** |  | 60d | 2001-01-15 A | 2001-04-06 A |  | 100% |  | 2001-01-15 | 2001-04-06 | 60d |  |  |  | G2 | 1440h | 1440h | TSG | 2421 |  |  |  |  |  |  |  |
| 56 | 52.1.2.1 | Definition of enhanced countdown procedure |  | 60d | 2001-01-15 A | 2001-04-06 A |  | 100% |  | 2001-01-15 | 2001-04-06 | 60d |  |  | finish no earlier than 2001-04-06 | G2 | 480h | 480h | TSG | 2327 |  |  |  |  |  |  |  |
| 57 | 52.1.2.2 | Definition of enhanced TBF release procedure |  | 60d | 2001-01-15 A | 2001-04-06 A |  | 100% |  | 2001-01-15 | 2001-04-06 | 60d |  |  | finish no earlier than 2001-04-06 | G2 | 480h | 480h | TSG | 2328 |  |  |  |  |  |  |  |
| 58 | 52.1.2.3 | Definition of USF=FREE type polling mechanism on PDCH |  | 60d | 2001-01-15 A | 2001-04-06 A |  | 100% |  | 2001-01-15 | 2001-04-06 | 60d |  |  | finish no earlier than 2001-04-06 | G2 | 480h | 480h | TSG | 2329 |  |  |  |  |  |  |  |
| 59 | 53 | **Low Chip Rate TDD option** |  | 880d | 2000-07-19 A | 2003-12-02 |  | 76% | 208.03d | 2000-07-19 | 2003-09-25 | 832d | 261d |  |  | R1 | 25872h | 19687.3h | TSG | 1222 | LCRTDD | G. Yang, CWTS | Rel-4 | Tsukasa |  |  |  |
| 60 | 53.1 | Physical layer |  | 183d | 2000-07-19 A | 2001-03-30 A |  | 100% |  | 2000-07-19 | 2001-03-30 | 183d |  |  | finish no earlier than 2001-03-30 | R1 | 1464h | 1464h | TSG | 1223 | LCRTDD-Phys | G. Yang, CWTS |  |  |  |  |  |
| 61 | 53.2 | Layer 2 and layer 3 protocol aspects |  | 183d | 2000-07-19 A | 2001-03-30 A |  | 100% |  | 2000-07-19 | 2001-03-30 | 183d |  |  | finish no earlier than 2001-03-30 | R2 | 1464h | 1464h | TSG | 1224 | LCRTDD-L23 | Y. Liu, CWTS |  |  | BaAS |  |  |
| 62 | 53.3 | RF radio transmission/reception, system performance requirements and conformance testing |  | 165d | 2000-08-14 A | 2001-03-30 A |  | 100% |  | 2000-08-14 | 2001-03-30 | 165d |  |  | finish no earlier than 2001-03-30 | R4 | 1320h | 1320h | TSG | 1225 | LCRTDD-RF | D. Zhang, CWTS |  |  | BaAS |  |  |
| 63 | 53.4 | UE radio access capability |  | 165d | 2000-08-14 A | 2001-03-30 A |  | 100% |  | 2000-08-14 | 2001-03-30 | 165d |  |  | finish no earlier than 2001-03-30 | R2 | 1320h | 1320h | TSG | 1227 | LCRTDD-UErac | Y. Liu, CWTS |  |  | BaAS |  |  |
| 64 | 53.5 | Iub/Iur protocol aspects |  | 165d | 2000-08-14 A | 2001-03-30 A |  | 100% |  | 2000-08-14 | 2001-03-30 | 165d |  |  | finish no earlier than 2001-03-30 | R3 | 1320h | 1320h | TSG | 1228 | LCRTDD-IubIur | Y. Liu, CWTS |  |  | BaAS |  |  |
| 65 | 53.6 | **Low chiprate TDD interworking with GERAN** |  | 101d | 2000-09-01 A | 2001-01-19 A | 64 | 100% |  | 2000-09-01 | 2001-01-19 | 101d |  |  |  |  |  |  |  | 2262 |  |  |  | Paolo |  |  |  |
| 66 | 53.6.1 | Handover and Cell Selection / Reselection to UTRA 1.28 Mcps TDD |  | 101d | 2000-09-01 A | 2001-01-19 A |  | 100% |  | 2000-09-01 | 2001-01-19 | 101d |  |  | finish no earlier than 2001-01-19 |  |  |  |  | 2263 |  |  |  |  |  |  |  |
| 67 | 53.7 | Start Testing | milestone | 0d | 2001-09-03 | 2001-09-03 | 65 |  |  | 2001-09-03 | 2001-09-03 | 0d | 571.11d | 10d | start no earlier than 2001-09-03 | MLST |  |  |  | 1911 |  |  |  |  |  |  |  |
| 68 | 53.8 | **Conformance Test Aspects - Low Chip Rate TDD** |  | 577d | 2001-09-17 A | 2003-12-02 | 67 | 52% | 276.89d | 2001-09-17 | 2003-09-25 | 529d | 261d |  |  | T1 | 12088h | 6287.31h |  | 2103 |  |  |  |  |  | 0% |  |
| 69 | 53.8.1 | Testing Layer 2 and layer 3 protocol aspects |  | 468d | 2001-09-17 A | 2003-07-02 |  | 60% | 187.2d | 2001-09-17 | 2002-12-02 | 316d | 370d |  | finish no earlier than 2003-07-02 | T1 | 3744h | 2246.4h | TSG | 2217 |  |  |  |  |  | 34.123-1, 34.123-2 |  |
| 70 | 53.8.2 | Testing Layer 2 and layer 3 protocol aspects - TTCN |  | 261d | 2002-12-03 | 2003-12-02 |  |  |  | 2002-12-03 | 2003-09-25 | 213d | 261d |  | finish no earlier than 2003-12-02 | T1 | 2088h |  | TSG |  |  |  |  |  |  | 34.123-3 |  |
| 71 | 53.8.3 | Testing RF Radio Transmission and Reception |  | 205d | 2001-09-17 A | 2002-06-28 A |  | 100% |  | 2001-09-17 | 2002-06-28 | 205d |  |  | finish no earlier than 2002-06-28 | T1 | 1640h | 1640h | TSG | 2218 |  |  |  |  |  |  |  |
| 72 | 54 | **Enable bearer independent CS architecture** |  | 565d | 2000-01-03 A | 2002-03-01 |  | 80% | 114.5d | 2000-01-03 | 2002-03-01 | 565d | 718d |  |  | S2 | 20176h | 13788h | TSG |  | CSSPLIT | Alexander Milinski, Siemens | Rel-4 | Kimmo |  |  |  |
| 73 | 54.1 | **Enable bearer-independent call control** |  | 424d | 2000-01-03 A | 2001-08-16 |  | 99% | 0d | 2000-01-03 | 2001-08-16 | 424d | 0d |  |  | N4 | 12336h | 8944h | WG | 1323 |  | Heinz-Peter Keutman, Ericsson |  |  | CCaR |  | Heinz-Peter.Keutmann@eed.ericsson.se |
| 74 | 54.1.1 | Architecture and Stage 2 description |  | 180d | 2000-01-03 A | 2000-09-08 A |  | 100% |  | 2000-01-03 | 2000-09-08 | 180d |  |  | finish no earlier than 2000-09-08 | S2 | 1440h | 1440h |  | 1516 |  |  |  |  | CCaR | 23.002 |  |
| 75 | 54.1.2 | Standardisation of protocols (control & user planes) over Nb interface |  | 64d | 2001-01-02 A | 2001-03-30 A |  | 100% |  | 2001-01-02 | 2001-03-30 | 64d |  |  | finish no earlier than 2001-03-30 | N3 | 512h | 512h | TSG | 1325 |  |  |  |  | CCaR |  |  |
| 76 | 54.1.3 | Standardisation of protocols over reference points between MSC server and Gateway MSC server |  | 130d | 2000-09-25 A | 2001-03-23 A |  | 100% |  | 2000-09-25 | 2001-03-23 | 130d |  |  | finish no earlier than 2001-03-23 | N4 | 1040h | 1040h | TSG | 1326 |  |  |  |  | CCaR |  |  |
| 77 | 54.1.4 | Standardisation of detailed stage 2 description |  | 180d | 2000-07-17 A | 2001-03-23 A |  | 100% |  | 2000-07-17 | 2001-03-23 | 180d |  |  | finish no earlier than 2001-03-23 | N4 | 1440h | 1440h | TSG | 1616 |  |  |  |  |  |  |  |
| 78 | 54.1.5 | **Bearer control between MSC server and MGW** |  | 250d | 2000-09-01 A | 2001-08-16 A |  | 100% |  | 2000-09-01 | 2001-08-16 | 250d |  |  |  | N4 | 4512h | 4512h | TSG | 1327 |  |  |  |  | CCaR |  |  |
| 79 | 54.1.5.1 | stage 3 - protocol issues |  | 250d | 2000-09-01 A | 2001-08-16 A |  | 100% |  | 2000-09-01 | 2001-08-16 | 250d |  |  | finish no earlier than 2001-08-16 | N4 | 2000h | 2000h | TSG | 1328 |  |  |  |  | CCaR |  |  |
| 80 | 54.1.5.2 | stage 3 - parameter value issues |  | 64d | 2001-01-02 A | 2001-03-30 A |  | 100% |  | 2001-01-02 | 2001-03-30 | 64d |  |  | finish no earlier than 2001-03-30 | N3 | 512h | 512h |  | 1329 |  |  |  |  | CCaR |  |  |
| 81 | 54.2 | Lawful interception |  | 155d | 2000-08-21 A | 2001-03-23 A |  | 100% |  | 2000-08-21 | 2001-03-23 | 155d |  |  | finish no earlier than 2001-03-23 | S3 | 1240h | 1240h |  | 1331 |  |  |  |  | CCaR |  |  |
| 82 | 54.3 | Start Testing | milestone | 0d | 2001-03-05 | 2001-03-05 |  |  |  | 2001-03-05 | 2001-03-05 | 0d | 718d | 0d | start no earlier than 2001-03-05 | MLST |  |  |  | 1918 |  |  |  |  |  |  |  |
| 83 | 54.4 | Conformance Test Aspects - Enable bearer independent CS architecture |  | 260d | 2001-03-05 | 2002-03-01 | 82 |  |  | 2001-03-05 | 2002-03-01 | 260d | 718d |  |  | T1 | 2080h |  |  |  | CSSPLIT-TEST |  |  |  |  | 0% |  |

Notes:
- 69: duration set to 6 months (was 0)
- 71: duration set to 6 months (was 0), finish date set
- 73: DAB 12.12.01 should be 100% hence closed
- 74: R00 stage 2 at least 80 % complete in TSGS #8 21.-23.6.2000
- 81: Requirements capture: S3#14 (Aug 00), Feature specification: S3#15 (Sep 00), Definition of architecture. Should be included in general LI work mentioned above.

| ID | WBS | Task | Duration | Start | Finish | Complete | Remaining | Baseline start | Baseline finish | Baseline duration | Total slack | Constraint | Resources | Work | Actual work | Text1 | Text2 | Text6 | Text7 | Text8 | Text9 | Text4 | Text5 | Text3 |
| --- | --- | --- | --- | --- | --- | --- | --- | --- | --- | --- | --- | --- | --- | --- | --- | --- | --- | --- | --- | --- | --- | --- | --- | --- |
| 84 | 55 | **MExE enhancements Rel-4** | 510d | 2000-01-03 A | 2001-12-14 A | 100% |  | 2000-01-03 | 2003-01-28 | 802d |  |  | T2 | 19024h | 19024h | MEXE | Ter | Rel-4 | TSG | Friedhelm | 1445 |  |  |  |
| 85 | 55.1 | **MExE Security Analysis Activity** | 474d | 2000-02-22 A | 2001-12-14 A | 100% |  | 2000-02-22 | 2001-12-14 | 474d |  |  | S3 | 8464h | 8464h | MEXE-SEC | Ter |  | TSG |  | 1447 | Colin Blanchard, BT | colin.blanchard@bt.com |  |
| 86 | 55.1.1 | Stage 3 | 370d | 2000-07-17 A | 2001-12-14 A | 100% |  | 2000-07-17 | 2001-12-14 | 370d |  | finish no earlier than 2001-12-14 | S3 | 2960h | 2960h | MEXE1-SEC | Ter |  |  |  | 2045 |  |  |  |
| 87 | 55.1.2 | Terminal aspects | 214d | 2000-02-22 A | 2000-12-15 A | 100% |  | 2000-02-22 | 2000-12-15 | 214d |  | finish no earlier than 2000-12-15 | T2 | 1712h | 1712h |  | Ter |  |  |  | 1448 |  |  |  |
| 88 | 55.2 | **MExE Rel4 Improvements and Investigations** | 250d | 2000-01-03 A | 2000-12-15 A | 100% |  | 2000-01-03 | 2000-12-15 | 250d |  |  | T2 | 6480h | 6480h | MEXE-ENHANC | Ter |  | TSG |  | 1810 | Mark CATALDO, Motorola | mcatald1@MOTOROLA.COM | 22.057, 23.057 |
| 89 | 55.2.1 | 3rd MExE classmark | 250d | 2000-01-03 A | 2000-12-15 A | 100% |  | 2000-01-03 | 2000-12-15 | 250d |  | finish no earlier than 2000-12-15 | T2 | 2000h | 2000h |  | Ter |  | TSG |  | 1812 | Mark CATALDO, Motorola | mcatald1@MOTOROLA.COM | 22.057, 23.057 |
| 90 | 55.2.2 | FS on Secure download mechanism and capabilities to support SDR concepts | 225d | 2000-02-07 A | 2000-12-15 A | 100% |  | 2000-02-07 | 2000-12-15 | 225d |  | finish no earlier than 2000-12-15 | T2 | 1800h | 1800h |  | Ter |  | TSG |  | 1814 | Mark CATALDO, Motorola | mcatald1@MOTOROLA.COM | 22.057, 23.057 |
| 91 | 55.2.3 | FS on Support of MP3/MPEG4 content | 225d | 2000-02-07 A | 2000-12-15 A | 100% |  | 2000-02-07 | 2000-12-15 | 225d |  | finish no earlier than 2000-12-15 | T2 | 1800h | 1800h |  | Ter |  | TSG |  | 1815 | Mark CATALDO, Motorola | mcatald1@MOTOROLA.COM | 22.057, 23.057 |
| 92 | 56 | **Tandem Free aspects for 3G and between 2G and 3G systems** | 344d | 2000-02-22 A | 2001-06-15 A | 100% |  | 2000-02-22 | 2001-06-15 | 344d |  |  | S4 | 9696h | 9696h | TFO | Cod | Rel-4 |  | Paolo | 1631 |  |  |  |
| 93 | 56.1 | **Tandem Free AMR** | 344d | 2000-02-22 A | 2001-06-15 A | 100% |  | 2000-02-22 | 2001-06-15 | 344d |  |  | S4 | 6944h | 6944h | TFO-AMR | Cod |  |  |  | 1632 |  |  |  |
| 94 | 56.1.1 | Specification | 284d | 2000-02-22 A | 2001-03-23 A | 100% |  | 2000-02-22 | 2001-03-23 | 284d |  | start no earlier than 2000-02-22 | S4 | 2272h | 2272h |  | Cod |  |  |  | 130 |  |  | 28.062 |
| 95 | 56.1.2 | **Impact on:** | 115d | 2001-01-08 A | 2001-06-15 A | 100% |  | 2001-01-08 | 2001-06-15 | 115d |  |  | NP | 1920h | 1920h |  | Cod |  |  |  | 907 |  |  |  |
| 96 | 56.1.2.1 | CN | 60d | 2001-03-26 A | 2001-06-15 A | 100% |  | 2001-03-26 | 2001-06-15 | 60d |  | finish no earlier than 2001-06-15 | NP | 480h | 480h |  | Cod |  |  |  | 131 |  |  |  |
| 97 | 56.1.2.2 | GERAN | 65d | 2001-01-08 A | 2001-04-06 A | 100% |  | 2001-01-08 | 2001-04-06 | 65d |  | finish no earlier than 2001-04-06 | GP | 520h | 520h |  | Cod |  |  |  | 132 |  |  |  |
| 98 | 57 | **Advanced Speech Call Items enhancements_REL-4** | 334d | 2000-12-03 A | 2002-03-14 A | 100% |  | 2000-12-03 | 2002-03-14 | 334d |  |  | N1 | 5925.6h | 5925.6h | ASCI |  | Rel-4 | TSG | Per | 2230 | Sonia Garapaty | sonia.garapaty@nortelnetworks.com |  |
| 99 | 57.1 | Stage 2 | 326.7d | 2000-12-03 A | 2002-03-14 A | 100% |  | 2000-12-03 | 2002-03-14 | 326.7d |  | finish no earlier than 2002-03-14 | N4 | 2613.6h | 2613.6h |  |  |  | WG | Kimmo | 2232 | Vivien Perlic, Sagem |  | 23.067, 24.067 |
| 100 | 57.2 | Stages 2 and 3 on A interface | 80d | 2000-12-03 A | 2001-03-23 A | 100% |  | 2000-12-03 | 2001-03-23 | 80d |  | finish no earlier than 2001-03-23 | N1 | 640h | 640h |  |  |  | WG | Per | 2231 | Sonia Garapaty | sonia.garapaty@nortelnetworks.com | 44.068, 44.069, 24.008 |
| 101 | 58 | **700 MHz spectrum support** | 775d | 2000-01-03 A | 2002-12-20 | 99% | 0d | 2000-01-03 | 2002-12-20 | 775d | 0d |  | GP | 25000h | 18800h | 700SS |  | Rel-4 |  | Paolo | 2403 |  |  |  |
| 102 | 58.1 | **GERAN support for the 700 MHz band** | 275d | 2000-01-03 A | 2001-01-19 A | 100% |  | 2000-01-03 | 2001-01-19 | 275d |  |  | GP | 8800h | 8800h |  |  |  |  |  | 2404 |  |  |  |
| 103 | 58.1.1 | Signalling support | 275d | 2000-01-03 A | 2001-01-19 A | 100% |  | 2000-01-03 | 2001-01-19 | 275d |  | finish no earlier than 2001-01-19 | GP | 2200h | 2200h |  |  |  |  |  | 2405 |  |  |  |
| 104 | 58.1.2 | Physical layer definitions | 275d | 2000-01-03 A | 2001-01-19 A | 100% |  | 2000-01-03 | 2001-01-19 | 275d |  | finish no earlier than 2001-01-19 | GP | 2200h | 2200h |  |  |  |  |  | 2406 |  |  |  |
| 105 | 58.1.3 | Receiver performance and RF budget | 275d | 2000-01-03 A | 2001-01-19 A | 100% |  | 2000-01-03 | 2001-01-19 | 275d |  | finish no earlier than 2001-01-19 | GP | 2200h | 2200h |  |  |  |  |  | 2407 |  |  |  |
| 106 | 58.2 | **GERAN MS Conformance test for 700 MHz band** | 175d | 2001-04-02 A | 2001-11-30 A | 100% |  | 2001-04-02 | 2001-11-30 | 175d |  |  | GP | 2800h | 2800h |  |  |  |  |  | 2408 |  |  |  |
| 107 | 58.2.1 | MS test | 175d | 2001-04-02 A | 2001-11-30 A | 100% |  | 2001-04-02 | 2001-11-30 | 175d |  | finish no earlier than 2001-11-30 | GP | 1400h | 1400h |  |  |  |  |  | 2409 |  |  |  |

Notes:
- 85: Presentation to S3 of threats and countermeasures analysis: S3#15, Feature specification: S3#16. S3#18: WID updated
- 86: Analysis undertaken by T2. No additional analysis needed for Rel-4
- 89: Additional features for MExE R2000
- 92: RAN and CN to verify no problems for GSM terminals roaming in 3G R99
- 93: RAN and CN to verify UMTS_AMR_2 support
- 95: "Implementation" changed to "Impact on:" by A. Sultan (for better wording)
- 96: RAN and CN to verify UMTS_AMR_2 support
- 97: End date Modified from June to March to have it in Rel4
- 98: Approved in TSGN_10
- 99: CN4#11 30/11/02: no inputs received in CN4

| ID | WBS | Task | Duration | Start | Finish | Complete | Remaining | Baseline start | Baseline finish | Baseline duration | Total slack | Constraint | Resources | Work | Actual work | Text8 | Text9 | Text1 | Text5 | Text6 | Text7 | Text3 | Text2 |
| --- | --- | --- | --- | --- | --- | --- | --- | --- | --- | --- | --- | --- | --- | --- | --- | --- | --- | --- | --- | --- | --- | --- | --- |
| 108 | 58.3 | **GERAN BTS Conformance test for 700 MHz band** | 450d | 2001-04-02 A | 2002-12-20 A | 100% |  | 2001-04-02 | 2002-12-20 | 450d |  |  | GP | 7200h | 7200h | Paolo | 2410 |  |  |  |  |  |  |
| 109 | 58.3.1 | BTS test | 450d | 2001-04-02 A | 2002-12-20 A | 100% |  | 2001-04-02 | 2002-12-20 | 450d |  | finish no earlier than 2002-12-20 | GP | 3600h | 3600h |  | 2411 |  |  |  |  |  |  |
| 110 | 59 | Operator Determined Barring for Packet Oriented Services | 208d | 2000-06-01 A | 2001-03-19 A | 100% |  | 2000-06-01 | 2001-03-19 | 208d |  | finish no earlier than 2001-03-19 | NP | 1664h | 1664h |  | 2463 | ODB | tamurato@nsf.ncos.nec.co.jp | Rel-4 | TSG |  |  |
| 111 | 60 | **UMTS QoS Architecture for PS Domain** | 758d | 2000-01-03 A | 2002-11-27 | 61% | 295.18d | 2000-01-03 | 2002-11-27 | 758d | 525d |  | S2 | 54256h | 20605.3h |  |  | QoSPS | Ina.widegren@era.ericsson.se | Rel-4 | TSG |  |  |
| 112 | 60.1 | Architecture | 153d | 2000-06-05 A | 2001-01-03 A | 100% |  | 2000-06-05 | 2001-01-03 | 153d |  | finish no earlier than 2001-01-03 | S2 | 1224h | 1224h |  |  |  |  |  | TSG | 23.107 |  |
| 113 | 60.2 | Charging and OAM&P for QoS Management | 201d | 2001-09-21 A | 2002-06-28 A | 100% |  | 2001-09-21 | 2002-06-28 | 201d |  | finish no earlier than 2002-06-28 | S5 | 1608h | 1608h |  |  | QoSPS-OAM | Albert.Yuhan@voicestream.com; Michael.Truss@MOTOROLA.COM |  | TSG | 32-series |  |
| 114 | 60.3 | **RAB Quality of Service (re)Negotiation over Iu** | 155d | 2000-08-21 A | 2001-03-23 | 99% | 0d | 2000-08-21 | 2001-03-23 | 155d | 0d |  | R3 | 3648h | 2501.6h |  | 1681 | QoSPS-MAPEND-RABQoS |  |  | TSG | 25.413 |  |
| 115 | 60.3.1 | RAB Quality of Service Negotiation over Iu | 155d | 2000-08-21 A | 2001-03-23 A | 100% |  | 2000-08-21 | 2001-03-23 | 155d |  | finish no earlier than 2001-03-23 | R3 | 1240h | 1240h |  | 1991 | QoSPS-MAPEND-RABQoS-Negot |  |  | TSG |  |  |
| 116 | 60.3.2 | RAB Quality of Service Negotiation over Iu during relocation | 16d | 2001-03-02 A | 2001-03-23 A | 100% |  | 2001-03-02 | 2001-03-23 | 16d |  | start no earlier than 2001-03-02 | R3 | 128h | 128h |  | 2456 | QoSPS-MAPEND-RABQoS-NegotReloc |  |  | TSG |  |  |
| 117 | 60.3.3 | RAB Quality of Service Re-Negotiation over Iu | 130d | 2000-09-25 A | 2001-03-23 A | 100% |  | 2000-09-25 | 2001-03-23 | 130d |  | finish no earlier than 2001-03-23 | R3 | 1040h | 1040h |  | 1992 | QoSPS-MAPEND-RABQoS-ReNegot |  |  | TSG |  |  |
| 118 | 60.4 | **GERAN QoS Aspects - Handovers: maintenance of real-time QoS while moving between cells in the PLMN including inter-SGSN and SRNS relocation or possibly other mechanisms** | 500d | 2000-01-03 A | 2001-11-30 | 99% | 0d | 2000-01-03 | 2001-11-30 | 500d | 0d |  | GP | 14440h | 10544h | Paolo | 1553 | GERQoS |  |  | TSG |  | QoS |
| 119 | 60.4.1 | **Handover Concept for the PS domain** | 500d | 2000-01-03 A | 2001-11-30 | 99% | 0d | 2000-01-03 | 2001-11-30 | 500d | 0d |  | GP | 10440h | 6544h |  | 2306 |  |  |  | TSG |  |  |
| 120 | 60.4.1.1 | Stable RT handover report 25.936 including header removal | 13d | 2000-01-03 A | 2000-01-19 A | 100% |  | 2000-01-03 | 2000-01-19 | 13d |  | start no earlier than 2000-01-03 | GP | 104h | 104h |  | 2309 |  |  |  | TSG |  |  |
| 121 | 60.4.1.2 | Update of stage 2 | 292d | 2000-01-03 A | 2001-02-13 A | 100% |  | 2000-01-03 | 2001-02-13 | 292d |  | finish no earlier than 2001-02-13 | GP | 2336h | 2336h |  | 2307 |  |  |  | TSG |  |  |
| 122 | 60.4.1.3 | Update of relevant stage 3 specs -> RRC | 500d | 2000-01-03 A | 2001-11-30 A | 100% |  | 2000-01-03 | 2001-11-30 | 500d |  | finish no earlier than 2001-11-30 | G2 | 4000h | 4000h |  | 2308 |  |  |  | TSG |  |  |
| 123 | 60.5 | **GERAN MS Conformance test for inter-system and intra-system Packet data real-time Handover** | 324d | 2001-08-31 | 2002-11-27 |  |  | 2001-08-31 | 2002-11-27 | 324d | 525d |  | G4; R3 | 25920h |  |  |  | GERQoS-Mstest |  |  | TSG |  |  |
| 124 | 60.5.1 | **Handover for the PS domain** | 324d | 2001-08-31 | 2002-11-27 |  |  | 2001-08-31 | 2002-11-27 | 324d | 525d |  | G4; R3 | 20736h |  |  |  |  |  |  | TSG |  |  |
| 125 | 60.5.1.1 | Stable RT handover report 25.936 including header removal | 324d | 2001-08-31 | 2002-11-27 |  |  | 2001-08-31 | 2002-11-27 | 324d | 525d | finish no earlier than 2002-11-27 | G4; R3 | 5184h |  |  |  |  |  |  | TSG |  |  |
| 126 | 60.5.1.2 | Update of stage 2 | 324d | 2001-08-31 | 2002-11-27 |  |  | 2001-08-31 | 2002-11-27 | 324d | 525d | finish no earlier than 2002-11-27 | G4; R3 | 5184h |  |  |  |  |  |  | TSG |  |  |
| 127 | 60.5.1.3 | Update of relevant stage 3 specs | 324d | 2001-08-31 | 2002-11-27 |  |  | 2001-08-31 | 2002-11-27 | 324d | 525d | finish no earlier than 2002-11-27 | G4; R3 | 5184h |  |  |  |  |  |  | TSG |  |  |
| 128 | 60.6 | PS-domain handover for real-time services | 155d | 2000-08-28 A | 2001-03-30 A | 100% |  | 2000-08-28 | 2001-03-30 | 155d |  | finish no earlier than 2001-03-30 | R3 | 1240h | 1240h |  | 1685 | QoSPS-PSdoRTS |  |  | TSG |  | QoS |
| 129 | 60.7 | RAB QoS Renegotiation at Relocation | 58d | 2001-01-03 | 2001-03-23 |  |  | 2001-01-03 | 2001-03-23 | 58d | 963d | finish no earlier than 2001-03-23 | R3 | 464h |  |  |  |  |  |  | TSG | 25.851, 25.946 |  |
| 130 | 61 | small Technical Enhancements and Improvements for Rel4 | 325d | 2000-01-03 A | 2001-03-30 A | 100% |  | 2000-01-03 | 2001-03-30 | 325d |  |  | Generic | 2600h | 2600h |  | 1993 | TEI4 |  | Rel-4 | TSG |  |  |
| 131 | 62 | **Rel-4 Evolutions of the transport in the UTRAN** | 525d | 2000-08-21 A | 2002-08-23 | 69% | 162.5d | 2000-08-21 | 2002-08-23 | 525d | 593d |  | RP | 8600h | 6501.38h | Joern |  | ETRAN |  | NA | TSG |  |  |
| 132 | 62.1 | QoS optimisation for AAL2 connections over Iub and Iur interfaces | 160d | 2000-08-21 A | 2001-03-30 A | 100% |  | 2000-08-21 | 2001-03-30 | 160d |  | finish no earlier than 2001-03-30 | R3 | 1280h | 1280h |  | 12 | ETRAN-QoSAAL2 |  | Rel-4 | TSG |  | BaAS |
| 133 | 62.2 | Transport bearer modification procedure on Iub, Iur, and Iu | 130d | 2000-10-02 A | 2001-03-30 A | 100% |  | 2000-10-02 | 2001-03-30 | 130d |  | finish no earlier than 2001-03-30 | R3 | 1040h | 1040h |  | 1995 | ETRAN-MigrMod |  | Rel-4 | TSG |  |  |

Notes:
- 110: Completed WI missing from the P-plan Added for tracking / Text4: oshiyuki Tamura
- 111: Text4: Ina Widegren, Ericsson
- 113: Text4: Albert YUHAN (VoiceStream Wireless), Michael TRUSS (Motorola)
- 114: Text4: A. Molander, Ericsson
- 115: Text4: A. Molander, Ericsson
- 117: Text4: S. Irwin, Motorola
- 123: Still exist? To be clarified by GERAN4/5
- 128: Text4: A. Lansisalmi, Nokia
- 130: "Joker" WI, to be used for a Rel 4 CR not related to any feature and with very limited impact on the system
- 131: Text4: Francois Courau
- 132: Text4: T. Yoshimura, Japan Telecom
- 133: Text4: T. Yoshimura, Japan Telecom

| ID | WBS | Task | Duration | Start | Finish | Complete | Remaining | Baseline start | Baseline finish | Baseline duration | Total slack | Constraint | Resources | Work | Actual work | Text9 | Text1 | Text3 | Text2 | Text6 | Text8 | Text7 | Text4 | Text5 |
| --- | --- | --- | --- | --- | --- | --- | --- | --- | --- | --- | --- | --- | --- | --- | --- | --- | --- | --- | --- | --- | --- | --- | --- | --- |
| 134 | 62.3 | **Conformance Test Aspects of Rel-4 evolutions of the transport in UTRAN** | 130d | 2002-02-25 | 2002-08-23 |  |  | 2002-02-25 | 2002-08-23 | 130d | 593d |  | T1 | 2080h |  | 1834 |  |  |  |  |  |  |  |  |
| 135 | 62.3.1 | Testing RAB support enhancements | 130d | 2002-02-25 | 2002-08-23 |  |  | 2002-02-25 | 2002-08-23 | 130d | 593d | finish no earlier than 2002-08-23 | T1 | 1040h |  | 2208 | CT-RABS? | 34.108, 34. 121, 34.122, 34.123 pts 1,2, 34.123 pt 3 |  |  |  |  |  |  |
| 136 | 63 | **Rel-4 Evolutions of the transport in the CN** | 215d | 2000-05-29 A | 2001-03-23 A | 100% |  | 2000-05-29 | 2001-03-23 | 215d |  |  | N4 | 7968h | 7968h |  | CNTRSP |  | BaAS | NA | Kimmo |  |  |  |
| 137 | 63.1 | **IP Transport of CN protocols (e.g., CAP, MAP)** | 77d | 2000-12-07 A | 2001-03-23 A | 100% |  | 2000-12-07 | 2001-03-23 | 77d |  |  | N4 | 2808h | 2808h | 859 | SS7IP |  | BaAS | Rel-4 |  |  |  |  |
| 138 | 63.1.1 | **Stage 3** | 77d | 2000-12-07 A | 2001-03-23 A | 100% |  | 2000-12-07 | 2001-03-23 | 77d |  |  | N4 | 2192h | 2192h | 1679 |  |  |  |  |  |  |  |  |
| 139 | 63.1.1.1 | CAP | 77d | 2000-12-07 A | 2001-03-23 A | 100% |  | 2000-12-07 | 2001-03-23 | 77d |  | finish no earlier than 2001-03-23 | N2 | 616h | 616h | 2018 |  |  |  |  |  | WG |  |  |
| 140 | 63.1.1.2 | MAP | 77d | 2000-12-07 A | 2001-03-23 A | 100% |  | 2000-12-07 | 2001-03-23 | 77d |  | finish no earlier than 2001-03-23 | N4 | 616h | 616h | 2019 |  |  |  |  |  |  |  |  |
| 141 | 63.1.1.3 | BSSAP+ | 43d | 2001-01-15 A | 2001-03-14 A | 100% |  | 2001-01-15 | 2001-03-14 | 43d |  | finish no earlier than 2001-03-14 | N1 | 344h | 344h | 2253 | SS7IP-BSSAP+ |  | Loc |  |  | WG |  |  |
| 142 | 63.2 | **FS on Transport and control separation in the PS CN domain** | 215d | 2000-05-29 A | 2001-03-23 A | 100% |  | 2000-05-29 | 2001-03-23 | 215d |  |  | S2 | 3440h | 3440h | 1513 |  |  | BaAS | Rel-4 |  | TSG | Juan-Antonio Ibanez, Ericsson Deutschland | Juan-Antonio.Ibanez@eed.ericsson.se |
| 143 | 63.2.1 | Architectural impacts | 215d | 2000-05-29 A | 2001-03-23 A | 100% |  | 2000-05-29 | 2001-03-23 | 215d |  | finish no earlier than 2001-03-23 | S2 | 1720h | 1720h | 1615 |  |  | BaAS |  |  | WG |  |  |
| 144 | 64 | **Rel-4 Improvements of Radio Interface** | 700d | 2000-07-10 A | 2003-03-14 | 83% | 117.46d | 2000-07-10 | 2003-03-14 | 700d | 448d |  | RP | 28624h | 23247.4h |  | RInImp |  |  | NA | Tsukasa | TSG |  |  |
| 145 | 64.1 | UTRA repeater specification (master) | 183d | 2000-07-10 A | 2001-03-21 A | 100% |  | 2000-07-10 | 2001-03-21 | 183d |  | finish no earlier than 2001-03-21 | R4 | 1464h | 1464h | 1509 | RInImp-REP |  |  | Rel-4 |  | TSG | T. Kummetz, Mikom; Alf Ahlström, Allgon |  |
| 146 | 64.2 | DSCH power control improvement in soft handover | 140d | 2000-09-11 A | 2001-03-23 A | 100% |  | 2000-09-11 | 2001-03-23 | 140d |  | finish no earlier than 2001-03-23 | R1 | 1120h | 1120h | 1994 | RInImp-DSCHsho |  |  | Rel-4 |  | TSG | A. Toskala, Nokia |  |
| 147 | 64.3 | UMTS 1800 | 320d | 2000-09-25 A | 2001-12-14 A | 100% |  | 2000-09-25 | 2001-12-14 | 320d |  | finish no earlier than 2001-12-14 | R4 | 2560h | 2560h | 1996 | RInImp-UMTS18 |  |  | Rel indep |  | TSG | H. Benn, Motorola |  |
| 148 | 64.4 | UMTS 1900 | 195d | 2001-03-19 A | 2001-12-14 A | 100% |  | 2001-03-19 | 2001-12-14 | 195d |  | finish no earlier than 2001-12-14 | R4 | 1560h | 1560h | 2467 | RInImp-UMTS19 |  |  | Rel indep | Cesar | TSG | Howard Benn, Motorola |  |
| 149 | 64.5 | FS on High Speed downlink packet access | 155d | 2000-08-21 A | 2001-03-23 A | 100% |  | 2000-08-21 | 2001-03-23 | 155d |  | finish no earlier than 2001-03-23 | R2 | 1240h | 1240h | 1219 | RInImp-HSDPA |  |  |  |  | TSG | A. Ghosh, Motorola |  |
| 150 | 64.6 | FS on improved common DL channel for Cell-FACH state | 340d | 2000-09-11 A | 2001-12-28 A | 100% |  | 2000-09-11 | 2001-12-28 | 340d |  | finish no earlier than 2001-12-28 | R2 | 2720h | 2720h | 1510 | RInImp-DLCFACH |  |  |  |  | TSG | J. Kwak, GBT |  |
| 151 | 64.7 | **Conformance Test Spec. Rel-4 improvements in Radio Interface** | 375d | 2001-10-08 A | 2003-03-14 | 64% | 134.62d | 2001-10-08 | 2003-03-14 | 375d | 448d |  | T1 | 12360h | 7923.08h |  |  |  |  |  |  |  |  |  |
| 152 | 64.7.1 | Testing Improved usage of downlink resource in FDD for CCTrCHs of dedicated type | 140d | 2002-02-18 | 2002-08-30 |  |  | 2002-02-18 | 2002-08-30 | 140d | 588d | finish no earlier than 2002-08-30 | T1 | 1120h |  | 2212 |  |  |  |  |  |  |  |  |
| 153 | 64.7.2 | Testing Terminal Power saving features | 140d | 2002-02-18 | 2002-08-30 |  |  | 2002-02-18 | 2002-08-30 | 140d | 588d | finish no earlier than 2002-08-30 | T1 | 1120h |  | 2213 |  |  |  |  |  |  |  |  |
| 154 | 64.7.3 | Testing DSCH power control improvement in soft handover | 140d | 2002-02-18 | 2002-08-30 |  |  | 2002-02-18 | 2002-08-30 | 140d | 588d | finish no earlier than 2002-08-30 | T1 | 1120h |  | 2214 |  |  |  | Rel-4 |  |  |  |  |
| 155 | 64.7.4 | Testing UMTS 1800 | 180d | 2001-10-08 A | 2002-06-14 A | 100% |  | 2001-10-08 | 2002-06-14 | 180d |  | finish no earlier than 2002-06-14 | T1 | 1440h | 1440h | 2215 |  | 34.108, 34,121, 34.122, 34.123-1 |  | Rel indep |  | TSG |  |  |
| 156 | 64.7.5 | Testing UMTS 1900 | 180d | 2001-10-08 A | 2002-06-14 A | 100% |  | 2001-10-08 | 2002-06-14 | 180d |  | finish no earlier than 2002-06-14 | T1 | 1440h | 1440h | 2215 |  | 34.108, 34,121, 34.122, 34.123-1 |  | Rel indep |  | TSG |  |  |
| 157 | 64.7.6 | Testing UMTS 1800 - TTCN | 195d | 2002-06-17 A | 2003-03-14 A | 100% |  | 2002-06-17 | 2003-03-14 | 195d |  | finish no earlier than 2003-03-14 | T1 | 1560h | 1560h |  |  | 34.123-3 |  | Rel indep |  | TSG |  |  |
| 158 | 64.7.7 | Testing UMTS 1900 - TTCN | 195d | 2002-06-17 A | 2003-03-14 A | 100% |  | 2002-06-17 | 2003-03-14 | 195d |  | finish no earlier than 2003-03-14 | T1 | 1560h | 1560h |  |  | 34.123-3 |  | Rel indep |  | TSG |  |  |

Notes:
- 135: Requires supporting companies
- 136: WI formulation assigned to N4
- 137: AS: corrected to Rel4 as stated at SA#10
- 142: Rel4 added
- 150: Stopped at RAN#14
- 152: start/finish dates set / Not started yet due to lack of supporting companies
- 153: start/finish dates set / Not started yet due to lack of supporting companies
- 154: start/finish dates set / Not started yet due to lack of supporting companies
- 155: finish date set
- 156: finish date set
- 157: finish date set
- 158: finish date set

| ID | WBS | Task | Type | Duration | Start | Finish | Predecessors | Complete | Remaining | Baseline start | Baseline finish | Baseline duration | Total slack | Free slack | Constraint | Resources | Work | Actual work | Text1 | Text6 | Text7 | Text8 | Text2 | Text4 | Text9 | Text3 | Text5 |
| --- | --- | --- | --- | --- | --- | --- | --- | --- | --- | --- | --- | --- | --- | --- | --- | --- | --- | --- | --- | --- | --- | --- | --- | --- | --- | --- | --- |
| 159 | 65 | **Rel-4 RAN improvements** |  | 938d? | 2000-08-14 A | 2004-03-17 |  | 17% | 783.05d? | 2000-08-14 | 2003-09-30 | 817d | 185d |  |  | RP | 29336h | 4185.39h | RANimp | NA | TSG | Cesar |  |  |  |  |  |
| 160 | 65.1 | Node B synchronisation for TDD |  | 160d | 2000-08-14 A | 2001-03-23 A |  | 100% |  | 2000-08-14 | 2001-03-23 | 160d |  |  | finish no earlier than 2001-03-23 | R1 | 1280h | 1280h | RANimp-NBsync | Rel-4 | TSG |  | BaAS | S. Oestreich, Siemens | 655 |  |  |
| 161 | 65.2 | RAB support enhancement for Rel-4 |  | 155d | 2000-08-21 A | 2001-03-23 A |  | 100% |  | 2000-08-21 | 2001-03-23 | 155d |  |  | finish no earlier than 2001-03-23 | R2 | 1240h | 1240h | RANimp-RABSE | Rel-4 | TSG |  |  | M. Israelsson, A. Krishnarajah, Ericsson | 2206 |  |  |
| 162 | 65.3 | Start Testing | milestone | 0d | 2001-12-03 | 2001-12-03 |  |  |  | 2001-12-03 | 2001-12-03 | 0d | 207d | 21d | start no earlier than 2001-12-03 | MLST |  |  |  |  |  |  |  |  | 1912 |  |  |
| 163 | 65.4 | **Conformance Test Aspects - Rel-4 RAN Improvements** |  | 577d? | 2002-01-01 A | 2004-03-17 | 162 | 2% | 564.28d? | 2002-01-01 | 2003-09-30 | 456d | 185d |  |  | T1 | 19312h | 425.76h |  |  |  |  |  |  | 2102 | 0% |  |
| 164 | 65.4.1 | Testing Radio access bearer support enhancments |  | 175d | 2002-01-01 | 2002-09-02 |  |  |  | 2002-01-01 | 2002-09-02 | 175d | 587d |  | finish no earlier than 2002-09-02 | T1 | 1400h |  |  |  |  |  |  |  | 2222 |  |  |
| 165 | 65.4.2 | Testing RAB support enhancements-Robust Header Compression |  | 332d | 2002-05-28 | 2003-09-03 |  |  |  | 2002-05-28 | 2003-03-03 | 200d | 325d |  | finish no earlier than 2003-09-03 | T1 | 2656h |  | RABimp-RoCH | Rel-4 | TSG |  |  |  | 2461 | 34.123-1, -2 |  |
| 166 | 65.4.3 | Testing RAB support enhancements-Robust Header Compression - TTCN |  | 472d | 2002-05-28 | 2004-03-17 |  |  |  | 2002-05-28 | 2003-06-30 | 285d | 185d |  | finish no earlier than 2004-03-17 | T1 | 3776h |  |  | Rel-4 | TSG |  |  |  |  | 34.123-3 |  |
| 167 | 65.4.4 | Testing of Extended Robut Header Compression |  | 270d | 2002-09-18 A | 2003-09-30 |  | 15% | 229.5d | 2002-09-18 | 2003-09-30 | 270d | 306d |  | finish no earlier than 2003-09-30 | T1 | 2160h | 324h | Ext-RoHC | Rel-4 | TSG |  |  |  |  | 34.123-1, -2 |  |
| 168 | 65.4.5 | Testing of Extended Robut Header Compression - TTCN |  | 325d | 2002-09-18 | 2003-12-16 |  |  |  | 2002-09-18 | 2003-09-30 | 270d | 251d |  | finish no earlier than 2003-12-16 | T1 | 2600h |  |  | Rel-4 | TSG |  |  |  |  | 34.123-3 |  |
| 169 | 24.4.6 | General changes to TS34.121 corresponding to release 4 |  | 263d? | 2003-03-03 | 2004-03-03 |  |  |  |  |  |  | 195d |  | finish no earlier than 2004-03-03 | T1 | 2104h |  | RANimp-test | Rel-4 | TSG |  |  |  |  | 34.108, 34.121 |  |
| 170 | 66 | **Rel-4 Emergency call enhancements** |  | 627d | 2000-01-03 A | 2002-05-28 |  | 64% | 227.72d | 2000-01-03 | 2002-05-28 | 627d | 656d |  |  | N1 | 7936h | 5161.18h | EMC1 | NA | WG | Per | CCaR | Mr Rouzbeh, Ericsson | 1652 |  | EUSFARO@am1.ericsson.se |
| 171 | 66.1 | **For CS based calls** |  | 627d | 2000-01-03 A | 2002-05-28 |  | 64% | 227.72d | 2000-01-03 | 2002-05-28 | 627d | 656d |  |  | N1 | 3600h | 2400h | EMC1-CS | Rel-4 | TSG |  | CCaR | Mr Rouzbeh, Ericsson | 1654 |  | EUSFARO@am1.ericsson.se |
| 172 | 66.1.1 | Distinction in CS domain of emergency call types to different emergency services |  | 40d | 2000-05-01 A | 2000-06-23 A |  | 100% |  | 2000-05-01 | 2000-06-23 | 40d |  |  | finish no earlier than 2000-06-23 | S1 | 320h | 320h |  |  |  |  | CCaR |  | 1320 |  |  |
| 173 | 66.1.2 | Distinction in CS domain of emergency calls to different emergency types |  | 22d | 2000-08-28 A | 2000-09-26 A |  | 100% |  | 2000-08-28 | 2000-09-26 | 22d |  |  | finish no earlier than 2000-09-22 | N1 | 176h | 176h |  |  |  |  |  |  | 1999 |  |  |
| 174 | 66.1.3 | Conformance Test Aspects - Emergency call enhancements |  | 150d | 2000-01-03 | 2000-07-28 |  |  |  | 2000-01-03 | 2000-07-28 | 150d | 1133d |  |  | T1 | 1200h |  |  |  |  |  |  |  | 2224 |  |  |
| 175 | 66.1.4 | Testing CS based emergency calls |  | 67d | 2002-02-25 A | 2002-05-28 A |  | 100% |  | 2002-02-25 | 2002-05-28 | 67d |  |  | finish no earlier than 2002-05-28 | T1 | 536h | 536h |  |  | TSG |  |  |  | 2226 | 34.123-1 |  |
| 176 | 66.1.5 | Testing CS based emergency calls - TTCN |  | 134d | 2001-11-22 A | 2002-05-28 A |  | 100% |  | 2001-11-22 | 2002-05-28 | 134d |  |  | finish no earlier than 2002-05-28 | T1 | 1072h | 1072h |  |  | TSG |  |  |  |  | 34.123-3 |  |
| 177 | 67 | **Rel-4 Terminal interfaces** |  | 314d | 2000-01-03 A | 2001-03-15 |  | 99% | 0d | 2000-01-03 | 2001-03-15 | 314d | 0d |  |  | T2 | 15651.6h | 10635.6h | TI | NA |  | Friedhelm | Ter |  | 1826 |  |  |
| 178 | 67.1 | **AT commands enhancements** |  | 313d | 2000-01-03 A | 2001-03-14 A |  | 100% |  | 2000-01-03 | 2001-03-14 | 313d |  |  |  | T2 | 5008h | 5008h | TI-ATC | Rel-4 |  |  | Ter |  | 1827 | 27.007 |  |
| 179 | 67.1.1 | Specification of AT commands for new services |  | 313d | 2000-01-03 A | 2001-03-14 A |  | 100% |  | 2000-01-03 | 2001-03-14 | 313d |  |  | finish no earlier than 2001-03-14 | T2 | 2504h | 2504h |  |  |  |  | Ter |  | 1828 | 27.007 |  |
| 180 | 67.2 | **Wide Area Data Synchronisation** |  | 313d | 2000-01-03 A | 2001-03-14 |  | 99% | 0d | 2000-01-03 | 2001-03-14 | 313d | 0d |  |  | T2 | 5655.2h | 3151.2h | TI-WADS | NA |  |  | Ter |  | 1829 |  |  |
| 181 | 67.2.1 | Continues evolution of Synchronisation protocol |  | 313d | 2000-01-03 A | 2001-03-14 A |  | 100% |  | 2000-01-03 | 2001-03-14 | 313d |  |  | finish no earlier than 2001-03-14 | T2 | 2504h | 2504h | TI-SYNC-EVOL | Rel-4 |  |  | Ter |  | 1830 | 27.903, 27.103 |  |
| 182 | 67.3 | Terminal local model |  | 218d | 2000-05-16 A | 2001-03-15 A |  | 100% |  | 2000-05-16 | 2001-03-15 | 218d |  |  | finish no earlier than 2001-03-15 | T2 | 1744h | 1744h | TLM | Rel-4 | TSG |  | Ter | Olga Tomé, Ericsson | 1832 | 23.227 | Olga.Tome@ECS.ERICSSON.SE |

Notes:
- 161: 29 Nov 2000: split into ROHC and non-ROHC part; 5 Mar 2001: splitting off of ROHC for Rel-4 agreed by R2
- 162: UID changed
- 164: duration set to 6 months (was 0) / Task not started due to lack of supporting companies
- 165: UID changed
- 166: UID changed
- 171: WI approved in TSG_10 / CN1#15: ID 2101 REMOVE-Emergency call recalling capability enhancement, no contributions
- 173: Calls to different emergency services such as ambulance, fire brigade, police, etc. can be routed to respective different emergency centres. / NP-000447 is the stage 3 changes for CS call control protocol.
- 174: UID changed
- 179: goal not completely achieved because of missing input
- 180: AS: Rel5 changed to Rel4 according to SA#10 decision, milestone on testing added

| ID | WBS | Task | Duration | Start | Finish | Complete | Remaining | Baseline start | Baseline finish | Baseline duration | Total slack | Constraint | Resources | Work | Actual work | Text1 | Text4 | Text6 | Text7 | Text8 | Text9 | Text2 | Text3 | Text5 |
| --- | --- | --- | --- | --- | --- | --- | --- | --- | --- | --- | --- | --- | --- | --- | --- | --- | --- | --- | --- | --- | --- | --- | --- | --- |
| 183 | 68 | **Rel-4 Location Services enhancements** | 455d | 2000-04-03 A | 2001-12-28 | 99% | 0d | 2000-04-03 | 2001-12-28 | 455d | 0d |  | S2 | 28240.8h | 21192.8h | LCS1 | Jan Kall, Nokia | NA | TSG | Alain | 1536 |  |  |  |
| 184 | 68.1 | CBS interactions | 455d | 2000-04-03 A | 2001-12-28 A | 100% |  | 2000-04-03 | 2001-12-28 | 455d |  | finish no earlier than 2001-12-28 | T2 | 3640h | 3640h | LCS1-CBS |  | Rel-4 |  |  | 2229 | Loc | 23.041 |  |
| 185 | 68.2 | LCS support in the CS domain | 180d | 2000-05-15 A | 2001-01-19 A | 100% |  | 2000-05-15 | 2001-01-19 | 180d |  | finish no earlier than 2001-01-19 | S2 | 1440h | 1440h | LCS1-CS |  | Rel-4 |  |  | 523 | Loc |  |  |
| 186 | 68.3 | **LCS support in the PS domain** | 435d | 2000-05-01 A | 2001-12-28 | 99% | 0d | 2000-05-01 | 2001-12-28 | 435d | 0d |  | S2 | 14164.8h | 10684.8h | LCS1-PS |  | Rel-4 |  |  | 525 |  |  |  |
| 187 | 68.3.1 | Stage 1 | 40d | 2000-07-03 A | 2000-08-25 A | 100% |  | 2000-07-03 | 2000-08-25 | 40d |  | start no earlier than 2000-07-03 | S1 | 320h | 320h |  | Randolph Wohlert, Pacific Bell Wireless |  |  |  | 1642 | Loc | 22.071 | rwohlert@tri.sbc.com |
| 188 | 68.3.2 | Stage 2 | 190d | 2000-05-01 A | 2001-01-19 A | 100% |  | 2000-05-01 | 2001-01-19 | 190d |  | finish no earlier than 2001-01-19 | S2 | 1520h | 1520h |  |  |  |  |  | 1181 |  | 23.271 |  |
| 189 | 68.3.3 | **Stage 3** | 355d | 2000-08-21 A | 2001-12-28 A | 100% |  | 2000-08-21 | 2001-12-28 | 355d |  |  | N1 | 8240h | 8240h |  |  |  |  |  | 1180 | Loc |  |  |
| 190 | 68.3.3.1 | Layer 3 LCS signaling UE (MS) -SGSN (UMTS PS and and GSM-GPRS) | 355d | 2000-08-21 A | 2001-12-28 A | 100% |  | 2000-08-21 | 2001-12-28 | 355d |  | finish no earlier than 2001-12-28 | N1 | 2840h | 2840h |  | Janne Muhonen / Nokia |  |  |  | 526 | Loc |  |  |
| 191 | 68.3.3.2 | MAP impacts of LCS | 160d | 2000-08-21 A | 2001-03-30 A | 100% |  | 2000-08-21 | 2001-03-30 | 160d |  | finish no earlier than 2001-03-30 | N4 | 1280h | 1280h |  |  |  |  |  | 2462 | Loc |  |  |
| 192 | 68.3.3.3 | GTP signaling for LCS | 160d | 2000-08-21 A | 2001-03-30 A | 100% |  | 2000-08-21 | 2001-03-30 | 160d |  | finish no earlier than 2001-03-30 | N4 | 1280h | 1280h |  |  |  |  |  | 527 | Loc |  |  |
| 193 | 68.4 | **UE positioning Rel-4** | 260d | 2000-04-03 A | 2001-03-30 A | 100% |  | 2000-04-03 | 2001-03-30 | 260d |  |  | RP | 4591.2h | 4591.2h | LCS1-UEpos |  | NA | TSG |  | 1600 |  |  |  |
| 194 | 68.4.1 | Iub/Iur interfaces for methods Rel 99 | 233.9d | 2000-04-03 A | 2001-03-30 A | 100% |  | 2000-04-03 | 2001-03-30 | 233.9d |  | finish no earlier than 2001-03-30 | R3 | 1871.2h | 1871.2h | LCS1-UEpos-IubIur | Yun-Chao Hu, Ericsson | Rel-4 | TSG |  | 1601 |  |  |  |
| 195 | 68.4.2 | UE positioning enhancements - IPDL for TDD | 150d | 2000-08-28 A | 2001-03-23 A | 100% |  | 2000-08-28 | 2001-03-23 | 150d |  | finish no earlier than 2001-03-23 | R2 | 1200h | 1200h | LCS1-UEpos-enh | M. Beckmann, Siemens | Rel-4 | TSG |  | 1602 |  |  |  |
| 196 | 69 | **Rel-4 UICC/(U)SIM enhancements and interworking** | 175d | 2000-07-24 A | 2001-03-23 A | 100% |  | 2000-07-24 | 2001-03-23 | 175d |  |  | T3 | 2800h | 2800h | UICC1 |  | NA |  | Claus | 1560 | Ter |  |  |
| 197 | 69.1 | Common PCN Handset Specification (CPHS) | 175d | 2000-07-24 A | 2001-03-23 A | 100% |  | 2000-07-24 | 2001-03-23 | 175d |  | finish no earlier than 2001-03-23 | T3 | 1400h | 1400h | UICC1-CPHS | ?, One2One | Rel-4 | TSG |  | 1799 | Ter | 27.103 |  |
| 198 | 70 | **Rel-4 (U)SIM toolkit enhancements** | 210d | 2000-06-05 A | 2001-03-23 A | 100% |  | 2000-06-05 | 2001-03-23 | 210d |  |  | T3 | 3360h | 3360h | USAT1 |  | NA |  | Claus | 1800 | Ter |  |  |
| 199 | 70.1 | USAT local link | 210d | 2000-06-05 A | 2001-03-23 A | 100% |  | 2000-06-05 | 2001-03-23 | 210d |  | finish no earlier than 2001-03-23 | T3 | 1680h | 1680h | USAT1-LocLnk | Jean-Francois Rubon (Gemplus) | Rel-4 | TSG |  | 2034 |  |  |  |
| 200 | 71 | **Rel-4 Security enhancements** | 575d | 2000-01-03 A | 2002-03-15 | 87% | 74.38d | 2000-01-03 | 2002-03-15 | 575d | 708d |  | S3 | 24144h | 20865.5h | SEC1 | Peter Howard, Vodafone | NA | TSG | Maurice |  |  |  | Peter.Howard@vodafone.com |
| 201 | 71.1 | Evolution of GSM CS algorithms (e.g. A5/3 development and deployment) | 271d | 2000-01-03 A | 2001-01-15 A | 100% |  | 2000-01-03 | 2001-01-15 | 271d |  | finish no earlier than 2001-01-15 | S3 | 2168h | 2168h | SEC1-CSALGO1 |  | Rel-4 | TSG |  | 1587 | Sec |  |  |
| 202 | 71.2 | **Evolution of GSM PS algorithms (e.g. GEA 2 deployment)** | 219d | 2000-02-22 A | 2000-12-22 A | 100% |  | 2000-02-22 | 2000-12-22 | 219d |  |  | S3 | 6024h | 6024h | SEC1-PSALGO1 |  | Rel-4 | TSG |  | 1588 | Sec |  |  |
| 203 | 71.2.1 | Main aspects | 199d | 2000-02-22 A | 2000-11-24 A | 100% |  | 2000-02-22 | 2000-11-24 | 199d |  | finish no earlier than 2000-11-24 | S3 | 1592h | 1592h |  |  |  |  |  | 1589 | Sec |  |  |
| 204 | 71.2.2 | Impact on GTP | 200d | 2000-03-20 A | 2000-12-22 A | 100% |  | 2000-03-20 | 2000-12-22 | 200d |  | finish no earlier than 2000-12-22 | N4 | 1600h | 1600h |  |  |  | WG |  | 1618 |  |  |  |
| 205 | 71.2.3 | GEA capability indication in MS CM | 135d | 2000-06-19 A | 2000-12-22 A | 100% |  | 2000-06-19 | 2000-12-22 | 135d |  | finish no earlier than 2000-12-22 | N1 | 1080h | 1080h | SEC1-PSALGO1-GEACAP | Duncan Mills / Vodafone Airtouch |  |  |  | 1661 | Sec |  |  |
| 206 | 71.3 | **MAP application layer security** | 575d | 2000-01-03 A | 2002-03-15 | 76% | 135.92d | 2000-01-03 | 2002-03-15 | 575d | 708d |  | S3 | 11352h | 8668.59h | SEC1-MAPAL |  | Rel-4 | TSG |  |  | Sec |  |  |
| 207 | 71.3.1 | Main aspects | 199d | 2000-02-21 A | 2001-03-29 A | 100% |  | 2000-02-21 | 2001-03-29 | 199d |  | start no earlier than 2000-02-21 | S3 | 1592h | 1592h |  |  |  | WG |  | 1584 | Sec |  |  |
| 208 | 71.3.2 | Other stage 3 aspects | 199d | 2000-02-22 A | 2000-11-24 A | 100% |  | 2000-02-22 | 2000-11-24 | 199d |  | finish no earlier than 2000-11-24 | N4 | 1592h | 1592h |  |  |  | TSG |  | 2025 | Sec |  |  |
| 209 | 71.3.3 | CHECK STATUS - Visibility and Configurability of security | 575d | 2000-01-03 A | 2002-03-15 | 60% | 230d | 2000-01-03 | 2002-03-15 | 575d | 708d | finish no earlier than 2002-03-15 | S3 | 4600h | 2760h | SEC1-VCS | Sébastien Nguyen Ngoc, France Telecom | Rel-5 | TSG |  | 1594 | Sec |  | Sebastien.nguyenngoc@rd.francetelecom.com |

Notes:
- 185: Only MAP impact foreseen so far. To be further split if needed.
- 187: To be also considered: External LCS client identity, and Privacy options when PDP-context and when no PDP-context is established
- 188: AS: 23.271 completed at SA#10
- 191: Missing work task
- 193: UID changed
- 194: 27/11: WG corrected; rapporteur corrected
- 195: 5 Mar 2001: splitting off of IPDL for TDD for Rel-4 agreed by R2
- 197: 28/5/2001: CRs approved at TP-11. WI complete.
- 199: 25/5/2001:CR was approved at TP-11. WI is complete
- 200: Added BB UE authentication and rapporteur added. TO BE DELETED
- 201: Algorithm development go-ahead at SA3#21. Scheduled for completion in August 2002?. Approved SA#17. DELETE ENTRY FROM REL-4?
- 202: A5/3 development will consider new GEA algorithm based on Kasumi.
- 203: Complete TSG#09 (09/2000). S3#17: Proposed for deletion. TO BE DELETED
- 206: TO DELETE: REPLACED BY NDS-MAP and NDS-IP. TO BE DELETED, but replacement NDS-MAP was missing. Completed Auto Key Management -> Rel-6
- 207: UID changed
- 208: UID changed
- 209: CR approved at SA3#21 awaiting comments from CN1.

| ID | WBS | Task | Type | Duration | Start | Finish | Predecessors | Complete | Remaining | Baseline start | Baseline finish | Baseline duration | Total slack | Free slack | Constraint | Resources | Work | Actual work | Text1 | Text3 | Text5 | Text6 | Text7 | Text8 | Text2 | Text9 |
| --- | --- | --- | --- | --- | --- | --- | --- | --- | --- | --- | --- | --- | --- | --- | --- | --- | --- | --- | --- | --- | --- | --- | --- | --- | --- | --- |
| 210 | 72 | **Rel-4 Charging and OAM&P** |  | 221d | 2000-12-01 A | 2001-10-05 A |  | 100% |  | 2000-12-01 | 2001-10-05 | 221d |  |  |  | S5 | 10472h | 10472h | OAM | 32-series | Albert.Yuhan@voicestream.com; Michael.Truss@MOTOROLA.COM | NA | TSG | Adrian |  |  |
| 211 | 72.1 | Rel4 Principles, high level Requirements and Architecture |  | 145d | 2000-12-01 A | 2001-06-21 A |  | 100% |  | 2000-12-01 | 2001-06-21 | 145d |  |  | finish no earlier than 2001-06-21 | S5 | 1160h | 1160h | OAM-AR/PR | 32.101, 32.102 | Michael.Truss@MOTOROLA.COM; Tommy.R.Berggren@TELIA.SE | Rel-4 | TSG |  | BCaM | 2089 |
| 212 | 72.2 | Rel4 Performance Management |  | 216d | 2000-12-01 A | 2001-09-28 A |  | 100% |  | 2000-12-01 | 2001-09-28 | 216d |  |  | finish no earlier than 2001-06-21 | S5 | 1728h | 1728h |  | 32.4xy, 52.402 | karl-heinz.nenner@t-mobile.de | Rel-4 | TSG |  | BCaM | 2088 |
| 213 | 72.3 | Fault Management |  | 221d | 2000-12-01 A | 2001-10-05 A |  | 100% |  | 2000-12-01 | 2001-10-05 | 221d |  |  | finish no earlier than 2001-06-21 | S5 | 1768h | 1768h |  | 32.111-1/4 | pjure@LUCENT.COM | Rel-4 | TSG |  | BCaM | 2081 |
| 214 | 72.4 | Configuration Management |  | 145d | 2000-12-01 A | 2001-06-21 A |  | 100% |  | 2000-12-01 | 2001-06-21 | 145d |  |  | finish no earlier than 2001-06-21 | S5 | 1160h | 1160h | OAM-CM | 32.106-1/8 | Thomas.Tovinger@emw.ericsson.se | Rel-4 | TSG |  | BCaM | 2082 |
| 215 | 72.5 | Rel4 Charging Management |  | 216d | 2000-12-01 A | 2001-09-28 A |  | 100% |  | 2000-12-01 | 2001-09-28 | 216d |  |  | finish no earlier than 2001-06-21 | S5 | 1728h | 1728h | OAM-CH | 32.2xy (Charging) | karl-heinz.nenner@t-mobile.de | Rel-4 | TSG |  | BCaM | 2083 |
| 216 | 72.6 | UTRAN Operations and Maintenance procedures |  | 145d | 2000-12-01 A | 2001-06-21 A |  | 100% |  | 2000-12-01 | 2001-06-21 | 145d |  |  | finish no earlier than 2001-06-21 | S5 | 1160h | 1160h | UOAM | 32.800 | bert.boden@d2mannesmann.de | Rel-4 | TSG | Adrian |  | 2071 |
| 217 | 73 | **Global Text Telephony** |  | 567d | 2000-06-28 A | 2002-08-29 |  | 82% | 101.67d | 2000-06-28 | 2002-08-29 | 567d | 589d |  |  | S2 | 9984h | 8388.85h | GTT |  | gunnar.hellstrom@omnitor.se | Rel Indep | TSG | Alain |  |  |
| 218 | 73.1 | Stage 1 |  | 188d | 2000-06-28 A | 2001-03-16 A |  | 100% |  | 2000-06-28 | 2001-03-16 | 188d |  |  | finish no earlier than 2000-12-22 | S1 | 1504h | 1504h |  | 22.976, 22.226 |  |  | TSG |  |  | 1634 |
| 219 | 73.2 | Stage 2 |  | 205d | 2000-09-11 A | 2001-06-22 A |  | 100% |  | 2000-09-11 | 2001-06-22 | 205d |  |  |  | S2 | 1640h | 1640h |  | 23.226 |  |  | TSG |  |  |  |
| 220 | 73.3 | **Specification of Cellular Text telephone Modem** |  | 136d | 2000-09-11 A | 2001-03-19 A |  | 100% |  | 2000-09-11 | 2001-03-19 | 136d |  |  |  | S4 | 2704h | 2704h | GTT-CTM |  |  |  |  |  |  | 2234 |
| 221 | 73.3.1 | General description and C-code |  | 66d | 2000-09-11 A | 2000-12-11 A |  | 100% |  | 2000-09-11 | 2000-12-11 | 66d |  |  | finish no earlier than 2000-12-11 | S4 | 528h | 528h |  | 26.226, 26.230 |  |  |  |  |  | 2238 |
| 222 | 73.3.2 | Minimum Performance requirements |  | 136d | 2000-09-11 A | 2001-03-19 A |  | 100% |  | 2000-09-11 | 2001-03-19 | 136d |  |  | finish no earlier than 2001-03-19 | S4 | 1088h | 1088h |  | 26.231 |  |  |  |  |  | 2237 |
| 223 | 73.4 | Start Testing | milestone | 0d | 2002-02-18 | 2002-02-18 |  |  |  | 2002-02-18 | 2002-02-18 | 0d | 598d | 9d | start no earlier than 2002-02-18 | MLST |  |  |  |  |  |  |  |  |  |  |
| 224 | 73.5 | Conformance Test Aspects - Global Text telephony |  | 130d | 2002-03-01 | 2002-08-29 | 223 |  |  | 2002-03-01 | 2002-08-29 | 130d | 589d |  | finish no earlier than 2002-08-29 | T1 | 1040h |  |  | 34.125 |  |  |  |  |  |  |

Notes:
- 210: az: WID appr.SA#13. / Text4: Albert YUHAN (VoiceStream Wireless), Michael TRUSS (Motorola)
- 211: Text4: Michael TRUSS (Motorola), Tommy BERGGREN (Telia AB)
- 212: Changed Rapp email / Text4: Karl-Heinz NENNER (T-Mobile)
- 213: Text4: Patrick JURÉ (Lucent Technologies)
- 214: Text4: Thomas TOVINGER (Ericsson)
- 215: Changed Rapp email / Text4: Karl-Heinz NENNER (T-Mobile)
- 216: Text4: Bert Boden (Mannesmann Mobilfunk)
- 217: SP-000162 agreed WI. Rapporteur / Gunnar Hellström, Ericsson Radio Systems AB, / email: gunnar.hellstrom@omnitor.se tel: +46 708 204 288 / Text4: Gunnar Hellström, Ericsson
- 224: Bearer services, new spec document? / This task requires supporting companies before it can start
